# se

Schedule from MS Project, 2007-01-19 to 2007-09-07, costs in $.

## Calendars

- Standard: Mon-Fri 08:00-12:00, 13:00-17:00; Sat-Sun off.

## Resources

| Resource | Rate |
| --- | --- |
| Sushil | 85 |
| Pushkar | 85 |
| Omkar | 85 |
| Prashant | 85 |
| Iftekar | 85 |
| Preeti | 85 |
| Aashish | 85 |

## Schedule

| ID | WBS | Task | Duration | Start | Finish | Predecessors | Baseline start | Baseline finish | Baseline duration | Total slack | Resources | Work | Cost |
| --- | --- | --- | --- | --- | --- | --- | --- | --- | --- | --- | --- | --- | --- |
| 1 | 1 | **Pre Project Planning** | 5d | 2007-01-19 | 2007-01-25 |  | 2007-01-19 | 2007-01-24 | 4d | 0d |  | 144h | 12,240 |
| 2 | 1.1 | Domain Study | 2d | 2007-01-19 | 2007-01-22 |  | 2007-01-19 | 2007-01-23 | 3d | 0d | Prashant; Omkar; Preeti | 48h | 4,080 |
| 3 | 1.2 | Technical Feasibility | 3d | 2007-01-23 | 2007-01-25 | 2 | 2007-01-24 | 2007-01-24 | 1d | 0d | Sushil; Aashish; Iftekar; Pushkar | 96h | 8,160 |
| 4 | 2 | Requirement Specification | 2d | 2007-01-26 | 2007-01-29 | 1 | 2007-01-25 | 2007-01-26 | 2d | 0d | Prashant; Iftekar | 32h | 2,720 |
| 5 | 3 | **Analysis** | 6d | 2007-01-30 | 2007-02-06 | 4 | 2007-01-29 | 2007-02-05 | 6d | 0d |  | 136h | 11,560 |
| 6 | 3.1 | Solicitation of solution | 3d | 2007-01-30 | 2007-02-01 |  | 2007-01-29 | 2007-01-31 | 3d | 0d | Sushil; Preeti; Iftekar | 72h | 6,120 |
| 7 | 3.2 | Hardware software allocation | 1d | 2007-02-02 | 2007-02-02 | 6 | 2007-02-01 | 2007-02-01 | 1d | 2d | Pushkar; Prashant | 16h | 1,360 |
| 8 | 3.3 | Data flow diagram | 3d | 2007-02-02 | 2007-02-06 | 6 | 2007-02-01 | 2007-02-05 | 3d | 0d | Omkar; Aashish | 48h | 4,080 |
| 9 | 4 | **Software Requirement Specification** | 7d | 2007-02-07 | 2007-02-15 | 5, 4 | 2007-02-06 | 2007-02-14 | 7d | 0d |  | 168h | 14,280 |
| 10 | 4.1 | Documentation | 5d | 2007-02-07 | 2007-02-13 |  | 2007-02-06 | 2007-02-12 | 5d | 0d | Preeti; Aashish; Pushkar | 120h | 10,200 |
| 11 | 4.2 | Customer Review | 2d | 2007-02-14 | 2007-02-15 | 10 | 2007-02-13 | 2007-02-14 | 2d | 0d | Prashant; Pushkar; Sushil | 48h | 4,080 |
| 12 | 5 | **Project Plan** | 2d | 2007-02-16 | 2007-02-19 | 9 | 2007-02-15 | 2007-02-16 | 2d | 0d |  | 112h | 9,520 |
| 13 | 5.1 | Resource Allocation | 2d | 2007-02-16 | 2007-02-19 |  | 2007-02-15 | 2007-02-16 | 2d | 0d | Omkar; Preeti | 32h | 2,720 |
| 14 | 5.2 | Metrics calculation | 2d | 2007-02-16 | 2007-02-19 |  | 2007-02-15 | 2007-02-16 | 2d | 0d | Sushil; Prashant | 32h | 2,720 |
| 15 | 5.3 | Risk Analysis | 2d | 2007-02-16 | 2007-02-19 |  | 2007-02-15 | 2007-02-16 | 2d | 0d | Iftekar; Pushkar; Aashish | 48h | 4,080 |
| 16 | 6 | **Design** | 47d | 2007-02-20 | 2007-04-25 | 12 | 2007-02-19 | 2007-04-10 | 37d | 0d |  | 1544h | 131,240 |
| 17 | 6.1 | **Architectural design** | 12d | 2007-02-20 | 2007-03-07 | 9, 12 | 2007-02-19 | 2007-02-27 | 7d | 0d |  | 360h | 30,600 |
| 18 | 6.1.1 | System modularization | 5d | 2007-02-20 | 2007-02-26 |  | 2007-02-19 | 2007-02-21 | 3d | 0d | Pushkar; Preeti | 80h | 6,800 |
| 19 | 6.1.2 | Data Structure Design | 7d | 2007-02-27 | 2007-03-07 | 18 | 2007-02-22 | 2007-02-27 | 4d | 0d | Sushil; Omkar | 112h | 9,520 |
| 20 | 6.1.3 | Control Flow Design | 7d | 2007-02-27 | 2007-03-07 | 18 | 2007-02-22 | 2007-02-27 | 4d | 0d | Prashant; Aashish; Iftekar | 168h | 14,280 |
| 21 | 6.2 | **High Level Design** | 16d | 2007-03-08 | 2007-03-29 | 17 | 2007-02-28 | 2007-03-14 | 11d | 0d |  | 688h | 58,480 |
| 22 | 6.2.1 | Main Module Design | 6d | 2007-03-08 | 2007-03-15 | 18 | 2007-02-28 | 2007-03-05 | 4d | 0d | Pushkar; Preeti; Sushil | 144h | 12,240 |
| 23 | 6.2.2 | User Interface Design | 10d | 2007-03-16 | 2007-03-29 | 22 | 2007-03-06 | 2007-03-14 | 7d | 0d | Aashish; Iftekar; Omkar; Prashant | 320h | 27,200 |
| 24 | 6.2.3 | Intermodular Interface Design | 7d | 2007-03-16 | 2007-03-26 | 18, 22 | 2007-03-06 | 2007-03-12 | 5d | 3d | Pushkar; Omkar; Prashant; Preeti | 224h | 19,040 |

| ID | WBS | Task | Duration | Start | Finish | Predecessors | Baseline start | Baseline finish | Baseline duration | Total slack | Free slack | Resources | Work | Cost |
| --- | --- | --- | --- | --- | --- | --- | --- | --- | --- | --- | --- | --- | --- | --- |
| 25 | 6.3 | **Low Level Design** | 19d | 2007-03-30 | 2007-04-25 | 21 | 2007-03-15 | 2007-04-10 | 19d | 0d |  |  | 496h | 42,160 |
| 26 | 6.3.1 | Helper Module Design | 4d | 2007-03-30 | 2007-04-04 |  | 2007-03-15 | 2007-03-20 | 4d | 0d |  | Sushil; Iftekar; Preeti | 96h | 8,160 |
| 27 | 6.3.2 | Desktop navigator module design | 8d | 2007-04-05 | 2007-04-16 | 26 | 2007-03-21 | 2007-03-30 | 8d | 0d |  | Sushil; Prashant | 128h | 10,880 |
| 28 | 6.3.3 | Internet Navigation Module Design | 7d | 2007-04-17 | 2007-04-25 | 26, 27 | 2007-04-02 | 2007-04-10 | 7d | 0d |  | Aashish; Sushil | 112h | 9,520 |
| 29 | 6.3.4 | Multimedia Module Design | 4d | 2007-04-17 | 2007-04-20 | 26, 27 | 2007-04-02 | 2007-04-05 | 4d | 3d |  | Omkar; Iftekar | 64h | 5,440 |
| 30 | 6.3.5 | Remote Monitoring and Logging Module Design | 5d | 2007-04-17 | 2007-04-23 | 26, 27 | 2007-04-02 | 2007-04-06 | 5d | 2d |  | Pushkar; Preeti | 80h | 6,800 |
| 31 | 6.3.6 | Appliance Management Module Design | 2d | 2007-04-17 | 2007-04-18 | 26, 27 | 2007-04-02 | 2007-04-05 | 4d | 5d |  | Prashant | 16h | 1,360 |
| 32 | 7 | Design Review | 4d | 2007-04-26 | 2007-05-01 | 17, 21, 25 | 2007-04-11 | 2007-04-16 | 4d | 93d |  | Prashant; Sushil; Iftekar; Preeti | 128h | 10,880 |
| 33 | 8 | **Test Case Planning** | 5d | 2007-04-26 | 2007-05-02 | 16 | 2007-04-11 | 2007-04-17 | 5d | 48d |  |  | 208h | 17,680 |
| 34 | 8.1 | Unit Testing Plan | 3d | 2007-04-26 | 2007-04-30 | 25 | 2007-04-11 | 2007-04-13 | 3d | 84d | 40d | Omkar; Preeti | 48h | 4,080 |
| 35 | 8.2 | Integration Testing Plan | 3d | 2007-04-26 | 2007-04-30 | 17, 21 | 2007-04-11 | 2007-04-13 | 3d | 48d |  | Prashant; Pushkar | 48h | 4,080 |
| 36 | 8.3 | System Testing Plan | 2d | 2007-04-26 | 2007-04-27 | 17, 21 | 2007-04-11 | 2007-04-12 | 2d | 52d |  | Aashish; Omkar | 32h | 2,720 |
| 37 | 8.4 | User Acceptance Testing Plan | 5d | 2007-04-26 | 2007-05-02 | 16 | 2007-04-11 | 2007-04-17 | 5d | 58d |  | Prashant; Sushil | 80h | 6,800 |
| 38 | 9 | Configuration Management Plan | 2d | 2007-04-26 | 2007-04-27 | 16 | 2007-04-11 | 2007-04-12 | 2d | 95d |  | Iftekar; Preeti | 32h | 2,720 |
| 39 | 10 | **Coding** | 43d | 2007-04-26 | 2007-06-25 | 21, 25 | 2007-04-11 | 2007-06-19 | 50d | 0d |  |  | 1400h | 119,000 |
| 40 | 10.1 | Helper Modules | 7d | 2007-04-26 | 2007-05-04 | 26 | 2007-04-11 | 2007-04-24 | 10d | 0d |  | Sushil; Iftekar; Preeti | 168h | 14,280 |
| 41 | 10.2 | Desktop Navigation | 18d | 2007-05-07 | 2007-05-30 | 27, 40 | 2007-04-25 | 2007-05-22 | 20d | 0d |  | Sushil; Prashant | 288h | 24,480 |
| 42 | 10.3 | Internet Navigation | 18d | 2007-05-31 | 2007-06-25 | 28, 40, 41 | 2007-05-23 | 2007-06-19 | 1mo | 0d |  | Aashish; Sushil | 288h | 24,480 |
| 43 | 10.4 | Multimedia Application | 18d | 2007-05-31 | 2007-06-25 | 29, 40, 41 | 2007-05-23 | 2007-06-19 | 1mo | 0d |  | Omkar; Iftekar | 288h | 24,480 |
| 44 | 10.5 | Remote Monitoring | 16d | 2007-05-31 | 2007-06-21 | 30, 40, 41 | 2007-05-23 | 2007-06-15 | 18d | 2d |  | Pushkar; Preeti | 256h | 21,760 |
| 45 | 10.6 | Applicance Management | 14d | 2007-05-31 | 2007-06-19 | 31, 40, 41 | 2007-05-23 | 2007-06-12 | 15d | 4d |  | Prashant | 112h | 9,520 |
| 46 | 11 | **Code Testing** | 10d | 2007-06-26 | 2007-07-09 | 39 | 2007-06-20 | 2007-07-03 | 10d | 44d |  |  | 160h | 13,600 |
| 47 | 11.1 | Unit Testing | 10d | 2007-06-26 | 2007-07-09 | 39, 34 | 2007-06-20 | 2007-07-03 | 10d | 44d |  | Omkar; Preeti | 160h | 13,600 |
| 48 | 12 | Integration | 8d | 2007-06-26 | 2007-07-05 | 39, 21 | 2007-06-20 | 2007-06-29 | 8d | 0d |  | Sushil; Aashish; Iftekar | 192h | 16,320 |
| 49 | 13 | Integration Testing | 3d | 2007-07-06 | 2007-07-10 | 35, 48 | 2007-07-02 | 2007-07-04 | 3d | 0d |  | Prashant; Pushkar | 48h | 4,080 |

| ID | WBS | Task | Duration | Start | Finish | Predecessors | Baseline start | Baseline finish | Baseline duration | Total slack | Resources | Work | Cost |
| --- | --- | --- | --- | --- | --- | --- | --- | --- | --- | --- | --- | --- | --- |
| 50 | 14 | **Testing** | 19d | 2007-07-11 | 2007-08-06 |  | 2007-07-05 | 2007-07-31 | 19d | 0d |  | 456h | 38,760 |
| 51 | 14.1 | System Testing | 9d | 2007-07-11 | 2007-07-23 | 36, 39, 49 | 2007-07-05 | 2007-07-17 | 9d | 0d | Omkar; Aashish; Preeti | 216h | 18,360 |
| 52 | 14.2 | User Acceptance Testing | 10d | 2007-07-24 | 2007-08-06 | 37, 51 | 2007-07-18 | 2007-07-31 | 10d | 0d | Prashant; Sushil; Iftekar | 240h | 20,400 |
| 53 | 15 | **User Documentation** | 4d | 2007-06-26 | 2007-06-29 |  | 2007-06-20 | 2007-06-25 | 4d | 26d |  | 224h | 19,040 |
| 54 | 15.1 | Developer Manual | 4d | 2007-06-26 | 2007-06-29 | 16, 39 | 2007-06-20 | 2007-06-25 | 4d | 26d | Sushil; Prashant; Aashish | 96h | 8,160 |
| 55 | 15.2 | User Manual | 4d | 2007-06-26 | 2007-06-29 | 16, 39 | 2007-06-20 | 2007-06-25 | 4d | 26d | Preeti; Pushkar; Iftekar; Omkar | 128h | 10,880 |
| 56 | 16 | **Delivery** | 9d | 2007-08-07 | 2007-08-17 |  | 2007-08-01 | 2007-08-13 | 9d | 0d |  | 184h | 15,640 |
| 57 | 16.1 | Hardware Setup | 2d | 2007-08-07 | 2007-08-08 | 50, 53 | 2007-08-01 | 2007-08-02 | 2d | 0d | Aashish; Iftekar | 32h | 2,720 |
| 58 | 16.2 | Software Installation | 2d | 2007-08-09 | 2007-08-10 | 57 | 2007-08-03 | 2007-08-06 | 2d | 0d | Prashant; Pushkar | 32h | 2,720 |
| 59 | 16.3 | Training | 5d | 2007-08-13 | 2007-08-17 | 57, 58 | 2007-08-07 | 2007-08-13 | 5d | 0d | Preeti; Sushil; Omkar | 120h | 10,200 |
| 60 | 17 | Support | 3w | 2007-08-20 | 2007-09-07 | 56 | 2007-08-14 | 2007-09-03 | 3w | 0d | Sushil; Pushkar; Iftekar; Preeti; Aashish; Prashant; Omkar | 840h | 71,400 |
